# 技术测试详细实施计划

Schedule from MS Project, 2015-01-20 to 2015-02-10.
中国建设银行

## Calendars

- 标准: Mon-Fri 08:00-12:00, 13:00-17:00; Sat-Sun off.

## Resources

| Resource |
| --- |
| ISV |
| HP |
| customer |
| 宗刚 |
| 曹海峰 |
| 邢玉飞 |
| 王雷 |
| 刑玉飞 |
| 工具开发人员 |
| 王强 |
| 章邦楼 |
| 樊秀菊 |
| 夏新茹 |

## Schedule

| ID | WBS | Task | Duration | Start | Finish | Predecessors | Total slack | Free slack | Constraint |
| --- | --- | --- | --- | --- | --- | --- | --- | --- | --- |
| 1 | 1 | **XX性能测试实施计划** | 16d? | 2015-01-20 | 2015-02-10 |  | 0d |  |  |
| 2 | 1.1 | **需求分析** | 5d? | 2015-01-20 | 2015-01-26 |  | 11d |  |  |
| 3 | 1.1.1 | 调研 | 2d? | 2015-01-20 | 2015-01-21 |  | 14d |  | start no earlier than 2015-01-20 |
| 4 | 1.1.2 | 分析报告 | 2d? | 2015-01-22 | 2015-01-23 |  | 11d | 0d | start no earlier than 2015-01-22 |
| 5 | 1.1.3 | 评审 | 1d? | 2015-01-26 | 2015-01-26 | 4 | 11d |  | start no earlier than 2015-01-23 |
| 6 | 1.2 | **测试准备** | 8d? | 2015-01-22 | 2015-02-02 |  | 0d |  |  |
| 7 | 1.2.1 | **测试前期准备** | 2d | 2015-01-22 | 2015-01-23 |  | 5d |  |  |
| 8 | 1.2.1.1 | 测试方案 | 2d | 2015-01-22 | 2015-01-23 |  | 5d |  | finish no earlier than 2015-01-23 |
| 9 | 1.2.2 | **测试环境准备** | 1d | 2015-01-26 | 2015-01-26 |  | 4d |  |  |
| 10 | 1.2.2.1 | 测试环境各软件版本、补丁确认 | 1d | 2015-01-26 | 2015-01-26 |  | 4d |  | start no earlier than 2015-01-26 |
| 11 | 1.2.2.2 | 应用程序安装与配置 | 1d | 2015-01-26 | 2015-01-26 |  | 4d |  | start no earlier than 2015-01-26 |
| 12 | 1.2.3 | **测试脚本、场景准备** | 2d? | 2015-01-26 | 2015-01-27 |  | 3d |  |  |
| 13 | 1.2.3.1 | **测试脚本开发** | 1d? | 2015-01-26 | 2015-01-26 |  | 4d |  |  |
| 14 | 1.2.3.1.1 | 脚本1 | 1d | 2015-01-26 | 2015-01-26 |  | 4d |  | start no earlier than 2015-01-26 |
| 15 | 1.2.3.1.2 | 脚本2 | 1d? | 2015-01-26 | 2015-01-26 |  | 4d |  | start no earlier than 2015-01-26 |
| 16 | 1.2.3.2 | 业务场景制定 | 1d | 2015-01-27 | 2015-01-27 |  | 3d |  | start no earlier than 2015-01-27 |
| 17 | 1.2.4 | **测试数据准备** | 3d | 2015-01-28 | 2015-01-30 |  | 0d |  |  |
| 18 | 1.2.4.1 | 基础数据导入 | 1d | 2015-01-28 | 2015-01-28 |  | 0d |  | start no earlier than 2015-01-28 |
| 19 | 1.2.4.2 | 参数化数据准备 | 1d | 2015-01-29 | 2015-01-29 | 18 | 0d |  |  |
| 20 | 1.2.4.3 | 参数化数据确认 | 1d | 2015-01-30 | 2015-01-30 | 19 | 0d |  |  |
| 21 | 1.2.5 | **准备检查确认** | 1d? | 2015-02-02 | 2015-02-02 |  | 0d |  |  |
| 22 | 1.2.5.1 | 准备工作确认检查 | 1d? | 2015-02-02 | 2015-02-02 | 7, 9, 12, 17 | 0d |  |  |
| 23 | 1.3 | **测试执行** | 2d? | 2015-02-03 | 2015-02-04 |  | 0d |  |  |
| 24 | 1.3.1 | **第一轮性能测试** | 1d? | 2015-02-03 | 2015-02-03 |  | 0d |  |  |
| 25 | 1.3.1.1 | xxxx | 1d? | 2015-02-03 | 2015-02-03 | 21 | 0d |  | start no earlier than 2011-01-25 |

| ID | WBS | Task | Duration | Start | Finish | Predecessors | Total slack | Constraint |
| --- | --- | --- | --- | --- | --- | --- | --- | --- |
| 26 | 1.3.2 | **第二轮性能测试** | 1d? | 2015-02-04 | 2015-02-04 |  | 0d |  |
| 27 | 1.3.2.1 | xxxx | 1d? | 2015-02-04 | 2015-02-04 | 24 | 0d | start no earlier than 2011-01-25 |
| 28 | 1.4 | **测试报告** | 3d? | 2015-02-05 | 2015-02-09 |  | 0d |  |
| 29 | 1.4.1 | 整理测试数据 | 1d? | 2015-02-05 | 2015-02-05 | 26 | 0d | start no earlier than 2011-01-25 |
| 30 | 1.4.2 | 编写测试分析报告 | 1d? | 2015-02-06 | 2015-02-06 | 29 | 0d |  |
| 31 | 1.4.3 | 报告评审 | 1d? | 2015-02-09 | 2015-02-09 | 30 | 0d |  |
| 32 | 1.5 | **测试总结** | 1d? | 2015-02-10 | 2015-02-10 |  | 0d |  |
| 33 | 1.5.1 | 测试项目总结 | 1d? | 2015-02-10 | 2015-02-10 | 28 | 0d |  |
